# ProyectoDigitalWallet

Schedule from MS Project, 2012-09-24 to 2012-12-06.
Hewlett-Packard

## Calendars

- DigitalWallet: Mon-Fri 09:00-13:00, 15:00-19:00; Sat-Sun off. Exceptions (off unless hours are given): 2012-10-15 (Festivo), 2012-11-05 (Festivo), 2012-11-12 (Festivo).

## Schedule

| ID | WBS | Task | Type | Duration | Start | Finish | Predecessors | Total slack |
| --- | --- | --- | --- | --- | --- | --- | --- | --- |
| 1 | 1 | **DISEÑO DE ALICACIÓN USSD** |  | 51d | 2012-09-24 | 2012-12-06 |  | 0d |
| 2 | 1.1 | **Definición y Conceptualización** |  | 7d | 2012-09-24 | 2012-10-02 |  | 0d |
| 3 | 1.1.1 | Definición de Solución |  | 3d | 2012-09-24 | 2012-09-26 |  | 0d |
| 4 | 1.1.2 | Solución Aceptada | milestone | 0d | 2012-09-26 | 2012-09-26 | 3 | 0d |
| 5 | 1.1.3 | Especificaciones Técnicas |  | 4d | 2012-09-27 | 2012-10-02 | 4 | 0d |
| 6 | 1.1.4 | Especificaciones Técnicas Aceptadas | milestone | 0d | 2012-10-02 | 2012-10-02 | 5 | 0d |
| 7 | 1.2 | **Diseño de Solución** |  | 5d | 2012-10-03 | 2012-10-09 | 6 | 0d |
| 8 | 1.2.1 | Detalle de la Solución |  | 1d | 2012-10-03 | 2012-10-03 |  | 0d |
| 9 | 1.2.2 | Solución Aceptada | milestone | 0d | 2012-10-03 | 2012-10-03 | 8 | 0d |
| 10 | 1.2.3 | Estudio de Diseño y Solución |  | 1d | 2012-10-04 | 2012-10-04 | 9 | 0d |
| 11 | 1.2.4 | Estudio de Diseño y Solución Aceptada | milestone | 0d | 2012-10-04 | 2012-10-04 | 10 | 0d |
| 12 | 1.2.5 | Selección de Software de implementación |  | 1d | 2012-10-05 | 2012-10-05 | 11 | 0d |
| 13 | 1.2.6 | Selección de Software de implementación Aceptado | milestone | 0d | 2012-10-05 | 2012-10-05 | 12 | 0d |
| 14 | 1.2.7 | Selección de Sofware Informatica de Diseño |  | 1d | 2012-10-08 | 2012-10-08 | 13 | 0d |
| 15 | 1.2.8 | Revisión Factibilidad Tecnica |  | 1d | 2012-10-09 | 2012-10-09 | 14 | 0d |
| 16 | 1.2.9 | Revisión Factibilidad Tecnica Aceptada | milestone | 0d | 2012-10-09 | 2012-10-09 | 15 | 0d |
| 17 | 1.3 | **Implementación Aplicación USSD** |  | 11d | 2012-10-10 | 2012-10-25 | 16 | 0d |
| 18 | 1.3.1 | Montaje de Solución |  | 2d | 2012-10-10 | 2012-10-11 |  | 0d |
| 19 | 1.3.2 | Montaje de Solución Aceptado | milestone | 0d | 2012-10-11 | 2012-10-11 | 18 | 0d |
| 20 | 1.3.3 | Salida a Producción |  | 9d | 2012-10-12 | 2012-10-25 | 19 | 0d |
| 21 | 1.3.4 | Arranque de proyecto aceptado | milestone | 0d | 2012-10-25 | 2012-10-25 | 20 | 0d |
| 22 | 1.4 | **Operación Aplicación USSD** |  | 3d | 2012-10-26 | 2012-10-30 | 21 | 0d |
| 23 | 1.4.1 | Puesta en Servicio |  | 3d | 2012-10-26 | 2012-10-30 |  | 0d |
| 24 | 1.4.2 | Puesta en Servicio Aceptado | milestone | 0d | 2012-10-30 | 2012-10-30 | 23 | 0d |

| ID | WBS | Task | Type | Duration | Start | Finish | Predecessors | Total slack |
| --- | --- | --- | --- | --- | --- | --- | --- | --- |
| 25 | 1.5 | **Garantía** |  | 2d | 2012-10-31 | 2012-11-01 | 24 | 0d |
| 26 | 1.5.1 | Definición de SLA |  | 2d | 2012-10-31 | 2012-11-01 |  | 0d |
| 27 | 1.5.2 | SLA Aceptado | milestone | 0d | 2012-11-01 | 2012-11-01 | 26 | 0d |
| 28 | 1.6 | **Soporte** |  | 15d | 2012-11-02 | 2012-11-26 | 27 | 0d |
| 29 | 1.6.1 | Soporte Operación |  | 15d | 2012-11-02 | 2012-11-26 |  | 0d |
| 30 | 1.6.2 | Soporte Operación Aceptado | milestone | 0d | 2012-11-26 | 2012-11-26 | 29 | 0d |
| 31 | 1.7 | **Capacitación** |  | 3d | 2012-11-27 | 2012-11-29 | 30 | 0d |
| 32 | 1.7.1 | Capacitación de Herramientas y Actualizaciones |  | 3d | 2012-11-27 | 2012-11-29 |  | 0d |
| 33 | 1.7.2 | Capacitación Aprobada | milestone | 0d | 2012-11-29 | 2012-11-29 | 32 | 0d |
| 34 | 1.8 | **Documentación** |  | 5d | 2012-11-30 | 2012-12-06 | 33 | 0d |
| 35 | 1.8.1 | Documentación de Problemas y Soluciones |  | 4d | 2012-11-30 | 2012-12-05 |  | 0d |
| 36 | 1.8.2 | Documentación Aprobado | milestone | 0d | 2012-12-05 | 2012-12-05 | 35 | 0d |
| 37 | 1.8.3 | Entrega Firma de Satisfacción del Cliente |  | 1d | 2012-12-06 | 2012-12-06 | 36 | 0d |
| 38 | 1.8.4 | Entrega a Satisfacción Aceptada | milestone | 0d | 2012-12-06 | 2012-12-06 | 37 | 0d |
